# project schedule

Schedule from MS Project, 2007-07-02 to 2008-06-30.
Augsburg College

## Calendars

- Standard: Mon-Fri 08:00-12:00, 13:00-17:00; Sat-Sun off.

## Schedule

| ID | WBS | Task | Type | Duration | Start | Finish | Predecessors | Total slack | Free slack | Constraint |
| --- | --- | --- | --- | --- | --- | --- | --- | --- | --- | --- |
| 1 | 1 | **Initiating** |  | 16d | 2007-07-02 | 2007-07-23 |  | 21d |  |  |
| 2 | 1.1 | Prepare stakeholder analysis |  | 3d | 2007-07-02 | 2007-07-04 |  | 21d | 0d |  |
| 3 | 1.2 | Prepare business case |  | 5d | 2007-07-05 | 2007-07-11 | 2 | 21d | 0d |  |
| 4 | 1.3 | Create project charter |  | 3d | 2007-07-12 | 2007-07-16 | 3 | 21d | 0d |  |
| 5 | 1.4 | Hold project kickoff meeting | milestone | 0d | 2007-07-16 | 2007-07-16 | 4 | 250d |  |  |
| 6 | 1.5 | Develop preliminary scope statement |  | 5d | 2007-07-17 | 2007-07-23 | 4 | 21d | 0d |  |
| 7 | 2 | **Planning** |  | 53d | 2007-07-05 | 2007-09-17 |  | 205d |  |  |
| 8 | 2.1 | **Project integration management** |  | 53d | 2007-07-05 | 2007-09-17 |  | 205d |  |  |
| 9 | 2.1.1 | Create team contract |  | 3d | 2007-07-05 | 2007-07-09 | 2 | 255d |  |  |
| 10 | 2.1.2 | Develop project management plan |  | 50d | 2007-07-10 | 2007-09-17 |  | 205d |  | start no earlier than 2007-07-09 |
| 11 | 2.2 | **Project scope management** |  | 10d | 2007-07-24 | 2007-08-06 |  | 205d |  |  |
| 12 | 2.2.1 | Develop scope statement |  | 7d | 2007-07-24 | 2007-08-01 | 6 | 205d | 0d |  |
| 13 | 2.2.2 | Create WBS and WBS dictionary |  | 3d | 2007-08-02 | 2007-08-06 | 12 | 205d | 0d |  |
| 14 | 2.3 | Project time management |  | 10d | 2007-08-07 | 2007-08-20 | 13 | 205d | 0d |  |
| 15 | 2.4 | Project cost management |  | 10d | 2007-08-07 | 2007-08-20 | 13 | 225d |  |  |
| 16 | 2.5 | Project quality management |  | 10d | 2007-08-07 | 2007-08-20 | 13 | 225d |  |  |
| 17 | 2.6 | Project human resource management |  | 10d | 2007-08-07 | 2007-08-20 | 13 | 225d |  |  |
| 18 | 2.7 | Project communications management |  | 10d | 2007-08-21 | 2007-09-03 | 14 | 215d |  |  |
| 19 | 2.8 | Project risk management |  | 10d | 2007-08-21 | 2007-09-03 | 14 | 215d |  |  |
| 20 | 2.9 | Project procurement management |  | 20d | 2007-08-21 | 2007-09-17 | 14 | 205d |  |  |
| 21 | 3 | **Executing** |  | 208.5d? | 2007-07-17 | 2008-05-02 |  | 26d |  |  |
| 22 | 3.1 | **Course design and development** |  | 94d | 2007-07-24 | 2007-11-30 |  | 21d |  |  |
| 23 | 3.1.1 | **Supplier management training:** |  | 94d | 2007-07-24 | 2007-11-30 |  | 21d |  |  |
| 24 | 3.1.1.1 | **Needs assessment** |  | 24d | 2007-07-24 | 2007-08-24 |  | 21d |  |  |
| 25 | 3.1.1.1.1 | Develop survey |  | 12d | 2007-07-24 | 2007-08-08 | 6 | 21d | 0d |  |
| 26 | 3.1.1.1.2 | Administer survey |  | 2d | 2007-08-09 | 2007-08-10 | 25 | 21d | 0d |  |
| 27 | 3.1.1.1.3 | Analyze survey results |  | 10d | 2007-08-13 | 2007-08-24 | 26 | 21d | 0d |  |
| 28 | 3.1.1.1.4 | Survey results reported to steering committee | milestone | 0d | 2007-08-24 | 2007-08-24 | 27 | 21d | 0d |  |
| 29 | 3.1.1.2 | Research of existing training |  | 15d | 2007-07-24 | 2007-08-13 | 6 | 230d |  |  |

| ID | WBS | Task | Type | Duration | Start | Finish | Predecessors | Total slack | Free slack |
| --- | --- | --- | --- | --- | --- | --- | --- | --- | --- |
| 30 | 3.1.1.3 | **Partnerships** |  | 25d | 2007-08-27 | 2007-09-28 |  | 21d |  |
| 31 | 3.1.1.3.1 | Research potential partners for providing training |  | 10d | 2007-08-27 | 2007-09-07 | 28 | 21d | 0d |
| 32 | 3.1.1.3.2 | Meet with potential partners |  | 10d | 2007-09-10 | 2007-09-21 | 31 | 21d | 0d |
| 33 | 3.1.1.3.3 | Develop partnership agreements |  | 5d | 2007-09-24 | 2007-09-28 | 32 | 21d | 0d |
| 34 | 3.1.1.4 | **Course development** |  | 40d | 2007-10-01 | 2007-11-23 |  | 21d |  |
| 35 | 3.1.1.4.1 | Develop executive course |  | 30d | 2007-10-01 | 2007-11-09 | 33 | 166d |  |
| 36 | 3.1.1.4.2 | Develop introductory course |  | 30d | 2007-10-01 | 2007-11-09 | 33 | 21d | 0d |
| 37 | 3.1.1.4.3 | Develop advanced course |  | 40d | 2007-10-01 | 2007-11-23 | 33 | 156d |  |
| 38 | 3.1.1.5 | **Pilot course** |  | 15d | 2007-11-12 | 2007-11-30 |  | 21d |  |
| 39 | 3.1.1.5.1 | Plan pilot course |  | 10d | 2007-11-12 | 2007-11-23 | 36 | 21d | 0d |
| 40 | 3.1.1.5.2 | Hold pilot course | milestone | 0d | 2007-11-23 | 2007-11-23 | 39 | 21d | 0d |
| 41 | 3.1.1.5.3 | Prepare report on pilot course |  | 3d | 2007-11-26 | 2007-11-28 | 40 | 21d | 0d |
| 42 | 3.1.1.5.4 | Review results of pilot course |  | 2d | 2007-11-29 | 2007-11-30 | 41 | 21d | 0d |
| 43 | 3.1.1.5.5 | Results reported to steering committee | milestone | 0d | 2007-11-30 | 2007-11-30 | 42 | 21d | 0d |
| 44 | 3.1.2 | Negotiating skills training |  | 80d | 2007-07-24 | 2007-11-12 | 6 | 55d | 0d |
| 45 | 3.1.3 | Project management training |  | 80d | 2007-07-24 | 2007-11-12 | 6 | 45d | 0d |
| 46 | 3.1.4 | Software applications training |  | 80d | 2007-07-24 | 2007-11-12 | 6 | 105d | 0d |
| 47 | 3.2 | **Course Administration** |  | 96d | 2007-12-14 | 2008-04-28 |  | 41d |  |
| 48 | 3.2.1 | First supplier management executive course completed | milestone | 0d | 2008-01-11 | 2008-01-11 | 43FS+30d | 21d | 0d |
| 49 | 3.2.2 | First supplier management introductory course completed | milestone | 0d | 2007-12-14 | 2007-12-14 | 43FS+10d | 51d | 0d |
| 50 | 3.2.3 | Second supplier management introductory course completed | milestone | 0d | 2008-01-25 | 2008-01-25 | 49FS+30d | 51d | 0d |
| 51 | 3.2.4 | Third supplier management introductory course completed | milestone | 0d | 2008-04-18 | 2008-04-18 | 50FS+60d | 51d |  |
| 52 | 3.2.5 | First supplier management advanced course | milestone | 0d | 2008-02-08 | 2008-02-08 | 43FS+50d | 101d |  |
| 53 | 3.2.6 | First negotiating skills course completed | milestone | 0d | 2008-01-21 | 2008-01-21 | 44FS+50d | 55d | 0d |
| 54 | 3.2.7 | Second negotiating skills course completed | milestone | 0d | 2008-04-14 | 2008-04-14 | 53FS+60d | 55d |  |
| 55 | 3.2.8 | First project management course completed | milestone | 0d | 2008-02-04 | 2008-02-04 | 45FS+60d | 45d | 0d |
| 56 | 3.2.9 | Second project management course completed | milestone | 0d | 2008-04-28 | 2008-04-28 | 55FS+60d | 45d |  |
| 57 | 3.2.10 | First software applications course completed | milestone | 0d | 2008-02-04 | 2008-02-04 | 46FS+60d | 105d |  |

| ID | WBS | Task | Type | Duration | Start | Finish | Predecessors | Total slack | Free slack | Constraint |
| --- | --- | --- | --- | --- | --- | --- | --- | --- | --- | --- |
| 58 | 3.3 | **Course Evaluation** |  | 79d? | 2008-01-14 | 2008-05-01 | 48 | 21d | 0d |  |
| 59 | 3.3.1 | Prepare evaluations of all courses |  | 76d? | 2008-01-14 | 2008-04-28 |  | 21d | 0d | finish no earlier than 2008-04-28 |
| 60 | 3.3.2 | Prepare summary of all evaluations |  | 3d | 2008-04-29 | 2008-05-01 | 59 | 21d | 0d |  |
| 61 | 3.3.3 | Summary of course evaluations reported to steering committee | milestone | 0d | 2008-05-01 | 2008-05-01 | 60 | 21d | 0d |  |
| 62 | 3.4 | **Stakeholder Communications** |  | 208.5d? | 2007-07-17 | 2008-05-02 |  | 41.5d |  |  |
| 63 | 3.4.1 | **Communications regarding project and changes to training** |  | 208d? | 2007-07-17 | 2008-05-01 |  | 42d |  |  |
| 64 | 3.4.1.1 | Prepare emails, posters, memos, and other information |  | 208d? | 2007-07-17 | 2008-05-01 |  | 42d |  | finish no earlier than 2008-05-01 |
| 65 | 3.4.1.2 | Plan and hold meetings |  | 208d? | 2007-07-17 | 2008-05-01 |  | 42d |  | finish no earlier than 2008-05-01 |
| 66 | 3.4.1.3 | Prepare information for the corporate intranet |  | 208d? | 2007-07-17 | 2008-05-01 |  | 42d |  | finish no earlier than 2008-05-01 |
| 67 | 3.4.2 | Communications regarding productivity improvements |  | 40d | 2008-03-07 | 2008-05-02 | 58FS-5% | 41.5d |  |  |
| 68 | 4 | Monitoring and Controlling |  | 240d | 2007-07-02 | 2008-05-30 |  | 21d |  | start no earlier than 2007-07-02 |
| 69 | 5 | Closing |  | 21d | 2008-05-02 | 2008-05-30 | 61 | 21d |  | start no earlier than 2008-05-01 |
| 70 | 6 | Project buffer |  | 21d | 2008-06-02 | 2008-06-30 |  | 0d |  | start no earlier than 2008-05-30 |
| 71 | 7 | Project must be completed by date | milestone | 0d | 2008-06-30 | 2008-06-30 |  | 0d |  | finish no earlier than 2008-06-30 |
